# AB-09 - ziekenhuisafbouw

Schedule from MS Project, 2003-01-12 to 2003-03-27, status date 2003-01-08.
BAM Nelissen Van Egteren

## Calendars

- ALLEEN WERKDAGEN: Mon-Fri 08:30-12:30, 13:00-17:00; Sat-Sun off. Exceptions (off unless hours are given): 2003-01-11 to 2003-01-12 08:30-12:30, 13:00-17:00, 2003-01-18 to 2003-01-19 08:30-12:30, 13:00-17:00, 2003-01-25 to 2003-01-26 08:30-12:30, 13:00-17:00, 2003-02-01 to 2003-02-02 08:30-12:30, 13:00-17:00, 2003-02-08 to 2003-02-09 08:30-12:30, 13:00-17:00, 2003-02-15 to 2003-02-16 08:30-12:30, 13:00-17:00, 2003-02-22 to 2003-02-23 08:30-12:30, 13:00-17:00, 2003-03-01 to 2003-03-02 08:30-12:30, 13:00-17:00, 2003-03-08 to 2003-03-09 08:30-12:30, 13:00-17:00, 2003-03-15 to 2003-03-16 08:30-12:30, 13:00-17:00, 2003-03-22 to 2003-03-23 08:30-12:30, 13:00-17:00.

## Schedule

| ID | WBS | Task | Type | Duration | Start | Finish | Predecessors | Total slack | Free slack |
| --- | --- | --- | --- | --- | --- | --- | --- | --- | --- |
| 1 | 1 | **AFBOUWFASE** |  | 75d | 2003-01-12 | 2003-03-27 |  | 0d |  |
| 2 | 1.1 | **inbouwfase** |  | 75d | 2003-01-12 | 2003-03-27 |  | 0d |  |
| 3 | 1.1.1 | plafond prim.leidingen vooraf | milestone | 0d | 2003-01-12 | 2003-01-12 |  | 75d |  |
| 4 | 1.1.2 | cementdekvloer aanbrengen |  | 10d | 2003-01-12 | 2003-01-21 |  | 0d |  |
| 5 | 1.1.3 | maatvoeren binnenwanden |  | 3d | 2003-01-22 | 2003-01-24 | 4SS+10d | 0d |  |
| 6 | 1.1.4 | vloersparingen boren |  | 4d | 2003-01-25 | 2003-01-28 | 5SS+3d | 0d |  |
| 7 | 1.1.5 | GM-wand frame+kozijnen |  | 10d | 2003-01-29 | 2003-02-07 | 6SS+4d | 0d |  |
| 8 | 1.1.6 | GM-wand 1e beplating aanbr. |  | 10d | 2003-02-03 | 2003-02-12 | 7SS+5d | 0d |  |
| 9 | 1.1.7 | GM-wand electra leid+dozen |  | 10d | 2003-02-08 | 2003-02-17 | 8SS+5d | 0d |  |
| 10 | 1.1.8 | GM-wand water+riolering |  | 10d | 2003-02-11 | 2003-02-20 | 9SS+3d | 0d |  |
| 11 | 1.1.9 | GM-wand leidingen afpersen |  | 2d | 2003-02-20 | 2003-02-21 | 10SS+9d | 0d |  |
| 12 | 1.1.10 | GM-wand sluitwand aanbr. |  | 10d | 2003-02-22 | 2003-03-03 | 11SS+2d | 0d |  |
| 13 | 1.1.11 | GM-wand egaliseren |  | 10d | 2003-02-27 | 2003-03-08 | 12SS+5d | 17d | 0d |
| 14 | 1.1.12 | wand brandwerende afdicht. |  | 5d | 2003-03-06 | 2003-03-10 | 13SS+7d | 17d |  |
| 15 | 1.1.13 | plafond CV leidingset mont. |  | 10d | 2003-02-27 | 2003-03-08 | 12SS+5d | 0d |  |
| 16 | 1.1.14 | plafond luchtkanalen monteren |  | 10d | 2003-03-01 | 2003-03-10 | 15SS+2d | 0d |  |
| 17 | 1.1.15 | plafond bekabeling in goten |  | 10d | 2003-03-03 | 2003-03-12 | 16SS+2d | 0d |  |
| 18 | 1.1.16 | plafond randlat aanbr. |  | 10d | 2003-03-05 | 2003-03-14 | 17SS+2d | 0d |  |
| 19 | 1.1.17 | plafond regeleenheid mont. |  | 10d | 2003-03-07 | 2003-03-16 | 18SS+2d | 0d |  |
| 20 | 1.1.18 | plafond bandraster mont. |  | 10d | 2003-03-09 | 2003-03-18 | 19SS+2d | 0d |  |
| 21 | 1.1.19 | plafond roosters mont. |  | 10d | 2003-03-11 | 2003-03-20 | 20SS+2d | 0d |  |
| 22 | 1.1.20 | bouwlaag opruimen |  | 2d | 2003-03-21 | 2003-03-22 | 21SS+10d | 0d |  |
| 23 | 1.1.21 | keuren bouw+installatie |  | 1d | 2003-03-23 | 2003-03-23 | 22SS+2d | 0d |  |
| 24 | 1.1.22 | herstelwerkzaamheden |  | 4d | 2003-03-24 | 2003-03-27 | 23SS+1d | 0d |  |
| 25 | 1.1.23 | keuringsrapport maken | milestone | 0d | 2003-03-27 | 2003-03-27 | 24SS+4d | 0d |  |

| ID | WBS | Task | Type | Duration | Start | Finish | Predecessors | Total slack | Free slack |
| --- | --- | --- | --- | --- | --- | --- | --- | --- | --- |
| 26 | 1.2 | **afwerkingsfase** |  | 35d | 2003-01-12 | 2003-02-15 |  | 10d |  |
| 27 | 1.2.1 | plafond platen inleggen |  | 10d | 2003-01-12 | 2003-01-21 |  | 10d | 0d |
| 28 | 1.2.2 | plafond luchtkleppen inregelen |  | 10d | 2003-01-14 | 2003-01-23 | 27SS+2d | 10d | 0d |
| 29 | 1.2.3 | wand spuitwerk aanbrengen |  | 10d | 2003-01-19 | 2003-01-28 | 28SS+5d | 10d | 0d |
| 30 | 1.2.4 | wand bekleding aanbrengen |  | 10d | 2003-01-24 | 2003-02-02 | 29SS+5d | 10d | 0d |
| 31 | 1.2.5 | vloer parket leggen |  | 10d | 2003-01-27 | 2003-02-05 | 30SS+3d | 10d | 0d |
| 32 | 1.2.6 | vloer tapijt leggen |  | 10d | 2003-01-28 | 2003-02-06 | 31SS+1d | 10d | 0d |
| 33 | 1.2.7 | vloer parket+tapijt beschermen |  | 10d | 2003-01-30 | 2003-02-08 | 32SS+2d | 10d | 0d |
| 34 | 1.2.8 | bouwlaag opruimen |  | 2d | 2003-02-09 | 2003-02-10 | 33SS+10d | 10d | 0d |
| 35 | 1.2.9 | bouwlaag keuren afwerking |  | 1d | 2003-02-11 | 2003-02-11 | 34SS+2d | 10d | 0d |
| 36 | 1.2.10 | herstelwerkzaamheden |  | 4d | 2003-02-12 | 2003-02-15 | 35SS+1d | 10d | 0d |
| 37 | 1.2.11 | keuringsrapport maken | milestone | 0d | 2003-02-15 | 2003-02-15 | 36SS+4d | 10d | 0d |
| 38 | 1.3 | **uitrustingsfase** |  | 30d | 2003-02-16 | 2003-03-17 |  | 10d |  |
| 39 | 1.3.1 | aanrechten+kasten monteren |  | 10d | 2003-02-16 | 2003-02-25 | 37 | 10d | 0d |
| 40 | 1.3.2 | binnendeuren afhangen |  | 10d | 2003-02-18 | 2003-02-27 | 39SS+2d | 10d | 0d |
| 41 | 1.3.3 | deuren hang+sluitwerk |  | 10d | 2003-02-20 | 2003-03-01 | 40SS+2d | 10d | 0d |
| 42 | 1.3.4 | sanitaire toestellen afmont. |  | 10d | 2003-02-21 | 2003-03-02 | 41SS+1d | 10d | 0d |
| 43 | 1.3.5 | kranen+accesoires afmont. |  | 10d | 2003-02-23 | 2003-03-04 | 42SS+2d | 10d | 0d |
| 44 | 1.3.6 | plafond armaturen afmont |  | 10d | 2003-02-25 | 2003-03-06 | 43SS+2d | 10d | 0d |
| 45 | 1.3.7 | electra schakelmateriaal afmont. |  | 10d | 2003-02-27 | 2003-03-08 | 44SS+2d | 10d | 0d |
| 46 | 1.3.8 | opleveringsfase |  | 1d | 2003-03-09 | 2003-03-09 | 45SS+10d | 10d | 0d |
| 47 | 1.3.9 | bouwlaag opruimen |  | 2d | 2003-03-10 | 2003-03-11 | 46SS+1d | 10d | 0d |
| 48 | 1.3.10 | bouwlaag keuren bouw+installatie |  | 2d | 2003-03-12 | 2003-03-13 | 47SS+2d | 10d | 0d |
| 49 | 1.3.11 | herstelwerkzaamheden |  | 4d | 2003-03-14 | 2003-03-17 | 48SS+2d | 10d | 0d |
| 50 | 1.3.12 | keuringsrapport maken | milestone | 0d | 2003-03-17 | 2003-03-17 | 49SS+4d | 10d |  |
